# Planning, PD&E (T2 CE) and Design.mpp

Schedule from Primavera P6, 2016-08-01 to 2021-08-25, data date 2016-08-01.
Must finish by 2021-08-25

## Calendars

- Standard: Mon-Sun off.

## Schedule

| ID | WBS | Activity | Duration | Start | Finish | Predecessors | Total float | Constraint | Stack/Buffer |
| --- | --- | --- | --- | --- | --- | --- | --- | --- | --- |
|  | 1 | **PLANNING ACTIVITIES** |  | 2016-08-01 | 2017-07-17 |  |  |  |  |
| 2 |  | District SWAT Planning Meeting (May take place 6 months to 5 years before SWAT Kickoff Meeting) | 1d | 2016-08-01 | 2016-08-01 |  | 0d | start on or after 2016-08-01 | 746 |
| 3 |  | District SWAT Strategy Meeting (6 months after the SWAT Planning Meeting when the Tentative Work Program has been submit | 2d | 2017-02-01 | 2017-02-02 | 2 FS+16.38d | 0d |  |  |
|  | 1.3 | **ETDM PROGRAMMING SCREEN** |  | 2017-03-03 | 2017-07-17 |  |  |  |  |
| 9 |  | ETDM PROGRAMMING SCREEN START/ADVANCE NOTIFICATION | 32d | 2017-03-31 | 2017-05-15 | 6, 7, 8 | 0d |  | 700, 224 |
| 10 |  | ETDM Programming Screen Responses | 44d | 2017-05-16 | 2017-07-14 | 9 | 0d |  |  |
| 11 |  | ETDM PROGRAMMING PRELIMINARY SUMMARY REPORT PUBLISHED | 1d | 2017-07-17 | 2017-07-17 | 10 | 0d |  | 701 |
|  | 1.3.1 | **ETDM Programming Screen Meeting** |  | 2017-03-03 | 2017-03-30 |  |  |  |  |
| 6 |  | ETDM Programming Screen PED | 20d | 2017-03-03 | 2017-03-30 | 3 FS+2.5d | 0d |  |  |
| 7 |  | ETDM Programming Screen Purpose and Need | 20d | 2017-03-03 | 2017-03-30 | 3 FS+2.5d | 0d |  |  |
| 8 |  | Planning Consistency Completion | 5d | 2017-03-03 | 2017-03-09 | 3 FS+2.5d | 15d |  | 710 |
|  | 2 | **PRE-PD&E ACTIVITIES** |  | 2017-08-01 | 2018-09-14 |  |  |  |  |
| 13 |  | SWAT Kickoff Meeting | 1d | 2017-08-01 | 2017-08-01 | 11 FS+1.25d | 0d |  | 747 |
| 14 |  | Assign PD&E Project Manager | 1d | 2017-08-02 | 2017-08-02 | 13 | 0d |  | 704 |
|  | 2.3 | **TRAFFIC ANALYSIS** |  | 2017-08-03 | 2018-01-04 |  |  |  |  |
| 16 |  | Traffic Methodology Meeting | 1d | 2017-08-03 | 2017-08-03 | 7, 14, 13 | 0d |  |  |
| 17 |  | Traffic Methodology Memorandum | 5d | 2017-08-04 | 2017-08-10 | 16 | 0d |  |  |
| 18 |  | Traffic Data Collection | 20d | 2017-08-11 | 2017-09-07 | 17 | 0d |  |  |
| 19 |  | Crash Data and Analysis | 20d | 2017-08-11 | 2017-09-07 | 17 | 60d |  |  |
| 20 |  | Prepare Traffic Projections | 30d | 2017-09-08 | 2017-10-19 | 18 | 0d |  |  |
| 21 |  | Prepare Capacity Analysis | 30d | 2017-10-20 | 2017-11-30 | 20 | 0d |  |  |
| 22 |  | Draft Project Traffic Analysis Report | 10d | 2017-12-01 | 2017-12-14 | 21, 19 | 0d |  |  |
| 23 |  | FDOT Review - Draft Project Traffic Analysis Report | 10d | 2017-12-15 | 2017-12-28 | 22 | 0d |  |  |
| 24 |  | Final Project Traffic Analysis Report | 5d | 2017-12-29 | 2018-01-04 | 23 | 0d |  | 757 |

| ID | WBS | Activity | Duration | Start | Finish | Predecessors | Total float | Free float | Constraint | Stack/Buffer |
| --- | --- | --- | --- | --- | --- | --- | --- | --- | --- | --- |
|  | 2.4 | **INTERCHANGE ACCESS REQUEST** |  | 2017-08-03 | 2018-09-14 |  |  |  |  |  |
| 26 |  | Initiate IJR/IMR/SIMR or IOAR | 1d | 2017-08-03 | 2017-08-03 | 9, 14 | 134d | 0d |  |  |
| 27 |  | Prepare MLOU | 5d | 2017-08-04 | 2017-08-10 | 26 | 134d | 0d |  |  |
| 28 |  | DIRC/SPO Review of MLOU | 10d | 2017-08-11 | 2017-08-24 | 27 | 134d | 0d |  |  |
| 29 |  | FHWA Review of MLOU | 20d | 2017-08-25 | 2017-09-21 | 28 | 134d | 60d |  |  |
| 30 |  | Develop Alternatives | 30d | 2017-12-15 | 2018-01-25 | 29, 22 | 74d | 0d |  |  |
| 31 |  | Perform Operational Analysis | 30d | 2018-01-26 | 2018-03-08 | 30 | 74d | 0d |  |  |
| 32 |  | Prepare Preliminary IMR/IJR | 45d | 2018-03-09 | 2018-05-10 | 31 | 74d | 0d |  |  |
| 33 |  | DIRC/SPO Reviw of Preliminary IJR/IMR | 10d | 2018-05-11 | 2018-05-24 | 32 | 74d | 0d |  |  |
| 34 |  | FHWA Review of Preliminary IJR/IMR | 20d | 2018-05-25 | 2018-06-21 | 33 | 74d | 0d |  |  |
| 35 |  | Prepare Final IJR/IMR | 30d | 2018-06-22 | 2018-08-02 | 34 | 74d | 0d |  |  |
| 36 |  | DIRC/SPO Review of Final IJR/IMR | 10d | 2018-08-03 | 2018-08-16 | 35 | 74d | 0d |  |  |
| 37 |  | FHWA Review of IJR/IMR | 20d | 2018-08-17 | 2018-09-13 | 36 | 74d | 0d |  |  |
| 38 |  | IJR/IMR Approval | 1d | 2018-09-14 | 2018-09-14 | 37 | 74d |  |  | 765 |
|  | 2.5 | **DESIGN RELATED ACTIVITIES** |  | 2017-09-14 | 2018-01-03 |  |  |  |  |  |
| 40 |  | Design Survey and ROW Mapping | 80d | 2017-09-14 | 2018-01-03 | 14 FS+3.75d | 1d |  |  |  |
| 41 |  | Geotechnical Investigations | 80d | 2017-09-14 | 2018-01-03 | 14 FS+3.75d | 1d |  |  |  |
| 42 |  | Pavement Coring Evaluation Report | 80d | 2017-09-14 | 2018-01-03 | 14 FS+3.75d | 1d |  |  |  |
|  | 2.6 | **DEVELOP SCOPE AND SCHEDULE** |  | 2018-01-05 | 2018-02-02 |  |  |  |  |  |
| 44 |  | Begin PD&E Scope and Schedule | 20d | 2018-01-05 | 2018-02-01 | 11, 24, 40, 41, 42 | 0d |  |  |  |
| 45 |  | PD&E SCOPE AND SCHEDULE COMPLETION | 1d | 2018-02-02 | 2018-02-02 | 44 | 0d |  |  | 703 |
|  | 2.7 | **PROCUREMENT** |  | 2018-02-05 | 2018-07-24 |  |  |  |  |  |
| 47 |  | PD&E Advertisement | 1d | 2018-02-05 | 2018-02-05 | 45 | 0d |  |  | 705 |
| 48 |  | Procurement | 120d | 2018-02-06 | 2018-07-23 | 45, 47 | 0d |  |  |  |
| 49 |  | Notice to Proceed | 1d | 2018-07-24 | 2018-07-24 | 48 | 0d |  | start on or after 2016-04-01 |  |

| ID | WBS | Activity | Duration | Start | Finish | Predecessors | Total float | Free float | Stack/Buffer |
| --- | --- | --- | --- | --- | --- | --- | --- | --- | --- |
|  | 3 | **PD&E STUDY** |  | 2018-07-25 | 2020-05-08 |  |  |  |  |
|  | 3.1 | **PROJECT MANAGEMENT** |  | 2018-07-25 | 2018-08-02 |  |  |  |  |
| 52 |  | TYPE 2 CE START | 1d | 2018-07-25 | 2018-07-25 | 49 | 0d |  | 706 |
| 53 |  | Prepare Project Management Plan | 5d | 2018-07-26 | 2018-08-01 | 52 | 0d |  |  |
| 54 |  | Prepare QC Plan | 5d | 2018-07-26 | 2018-08-01 | 52 | 0d |  |  |
| 55 |  | Project Kickoff Meeting with FDOT | 1d | 2018-08-02 | 2018-08-02 | 53, 54 | 0d |  |  |
|  | 3.2 | **PUBLIC INVOLVEMENT** |  | 2018-07-26 | 2020-03-17 |  |  |  |  |
| 57 |  | Prepare Public Involvement Plan | 20d | 2018-07-26 | 2018-08-22 | 52 | 133d | 31d |  |
| 58 |  | Public Involvement Data Collection | 45d | 2018-08-03 | 2018-10-04 | 55 | 102d | 0d |  |
|  | 3.2.3 | **Prepare for Public Kickoff Meeting** |  | 2018-10-05 | 2018-12-10 |  |  |  |  |
| 60 |  | Site Review | 1d | 2018-10-05 | 2018-10-05 | 89 FS-7.5d, 57, 58 | 102d | 0d | 365 |
| 61 |  | Newsletter | 20d | 2018-10-08 | 2018-11-02 | 60 | 102d | 0d |  |
| 62 |  | Newspaper Ad | 20d | 2018-10-08 | 2018-11-02 | 60 | 102d | 0d |  |
| 63 |  | Elected/Appointed/Property Owner Letters | 20d | 2018-10-08 | 2018-11-02 | 60 | 102d | 0d |  |
| 64 |  | Presentation/Display Material Review | 15d | 2018-11-05 | 2018-11-23 | 63, 61, 62 | 102d | 0d |  |
| 65 |  | Public Kickoff Meeting | 1d | 2018-11-26 | 2018-11-26 | 89, 86, 87, 88, 91, 92, 64 | 102d | 0d |  |
| 66 |  | Public Comment Period | 10d | 2018-11-27 | 2018-12-10 | 65 | 102d | 73d |  |
|  | 3.2.4 | **Prepare for Public Information Meeting** |  | 2019-03-22 | 2019-07-05 |  |  |  |  |
| 68 |  | Site Review | 1d | 2019-03-22 | 2019-03-22 | 110 FS-7.5d, 66 | 29d | 0d | 365 |
| 69 |  | Newsletter | 20d | 2019-03-25 | 2019-04-19 | 68 | 29d | 0d |  |
| 70 |  | Newspaper Ad | 20d | 2019-03-25 | 2019-04-19 | 68 | 29d | 0d |  |
| 71 |  | Elected/Appointed/Property Owner Letters | 20d | 2019-03-25 | 2019-04-19 | 68 | 29d | 0d |  |
| 72 |  | Presentation/Display Material Review | 15d | 2019-04-22 | 2019-05-10 | 68, 69, 70, 71 | 29d |  |  |
| 73 |  | Public Information Meeting | 1d | 2019-06-21 | 2019-06-21 | 110 FS+0.62d, 72, 34 | 0d |  | 292 |
| 74 |  | Public Comment Period | 10d | 2019-06-24 | 2019-07-05 | 73 | 0d |  |  |

| ID | WBS | Activity | Duration | Start | Finish | Predecessors | Total float | Free float | Stack/Buffer |
| --- | --- | --- | --- | --- | --- | --- | --- | --- | --- |
|  | 3.2.5 | **Prepare for Public Hearing** |  | 2019-10-29 | 2020-03-17 |  |  |  |  |
| 76 |  | Site Review | 20d | 2019-10-29 | 2019-11-25 | 74, 148 FS-10d | 358d | 0d | 366 |
| 77 |  | Newsletter | 20d | 2019-11-26 | 2019-12-23 | 76 | 358d | 0d |  |
| 78 |  | Newspaper Ad | 20d | 2019-11-26 | 2019-12-23 | 76 | 358d | 0d |  |
| 79 |  | Elected/Appointed/Property Owner Letters | 20d | 2019-11-26 | 2019-12-23 | 76 | 358d | 0d |  |
| 80 |  | Presentation/Display Material Review | 15d | 2019-12-24 | 2020-01-13 | 76, 77, 78, 79 | 358d | 20d |  |
| 81 |  | Notice of Public Availability | 15d | 2020-02-11 | 2020-03-02 | 80, 148 FS-0.62d, 120, 121, 38 | 338d | 0d |  |
| 82 |  | Public Hearing | 1d | 2020-03-03 | 2020-03-03 | 81, 80 | 338d | 0d | 262 |
| 83 |  | Public Comment Period | 10d | 2020-03-04 | 2020-03-17 | 82 | 338d | 0d |  |
|  | 3.3 | **ENGINEERING ANALYSIS** |  | 2018-08-03 | 2020-01-17 |  |  |  |  |
|  | 3.3.1 | **Data Collection** |  | 2018-08-03 | 2018-09-27 |  |  |  |  |
| 86 |  | Roadway Data Collection | 40d | 2018-08-03 | 2018-09-27 | 55 | 143d | 41d |  |
| 87 |  | Drainage Data Collection | 40d | 2018-08-03 | 2018-09-27 | 55 | 143d | 41d |  |
| 88 |  | Bridge Data Collection | 40d | 2018-08-03 | 2018-09-27 | 55 | 143d | 41d |  |
| 89 |  | Prepare Base Map | 40d | 2018-08-03 | 2018-09-27 | 55 | 143d | 41d |  |
|  | 3.3.2 | **Traffic Analysis** |  | 2018-08-03 | 2019-01-24 |  |  |  |  |
| 91 |  | Traffic Data Collection | 20d | 2018-08-03 | 2018-08-30 | 55 | 0d |  |  |
| 92 |  | Crash Data and Analysis | 20d | 2018-08-03 | 2018-08-30 | 55 | 163d | 61d |  |
| 93 |  | Prepare Traffic Projections | 30d | 2018-08-31 | 2018-10-11 | 91 | 0d |  |  |
| 94 |  | Prepare Capacity Analysis | 30d | 2018-10-12 | 2018-11-22 | 93 | 0d |  |  |
| 95 |  | Draft Project Traffic Analysis Report | 10d | 2018-11-23 | 2018-12-06 | 94 | 0d |  |  |
| 96 |  | FDOT Review - Draft Project Traffic Analysis Report | 10d | 2018-12-07 | 2018-12-20 | 95 | 0d |  |  |
| 97 |  | Final Project Traffic Analysis Report | 5d | 2018-12-21 | 2018-12-27 | 96 | 0d |  | 757 |
| 98 |  | Prepare 18Kip ESALs Traffic Data | 20d | 2018-12-28 | 2019-01-24 | 97 | 216d |  |  |

| ID | WBS | Activity | Duration | Start | Finish | Predecessors | Total float | Free float | Stack/Buffer |
| --- | --- | --- | --- | --- | --- | --- | --- | --- | --- |
|  | 3.3.3 | **Alternative Analysis** |  | 2018-12-07 | 2020-01-17 |  |  |  |  |
| 100 |  | Typical Sections Analysis | 30d | 2018-12-07 | 2019-01-17 | 95 | 55d |  |  |
| 101 |  | Complete Streets/Multi Modal Analysis | 30d | 2018-12-07 | 2019-01-17 | 95 | 55d |  |  |
| 102 |  | Concept Development | 40d | 2018-12-28 | 2019-02-21 | 94, 97, 38 | 0d |  |  |
| 103 |  | Access Management Analysis | 40d | 2018-12-28 | 2019-02-21 | 97 | 30d |  |  |
| 104 |  | Drainage Analysis | 30d | 2019-02-22 | 2019-04-04 | 102 | 0d |  |  |
| 105 |  | Utility Coordination & Analysis | 30d | 2019-02-22 | 2019-04-04 | 102 | 0d |  |  |
| 106 |  | Railroad Coordination | 30d | 2019-02-22 | 2019-04-04 | 102 | 0d |  |  |
| 107 |  | Evaluation Matrix (1st Draft) | 5d | 2019-04-05 | 2019-04-11 | 100, 101, 104, 105, 106, 103, 102 | 0d |  |  |
| 108 |  | Construction Cost Estimates (LRE) | 10d | 2019-04-12 | 2019-04-25 | 107 | 30d |  |  |
| 109 |  | Right-of-Way Analysis | 20d | 2019-04-12 | 2019-05-09 | 107 | 20d |  |  |
| 110 |  | Evaluation Matrix (2nd Draft) | 5d | 2019-06-07 | 2019-06-13 | 108, 109, 123, 124, 125, 126, 127, 128 | 0d |  |  |
| 111 |  | Refine Alternatives (based on public input) | 20d | 2019-07-08 | 2019-08-02 | 74 | 538d |  |  |
| 112 |  | Prepare 1st DRAFT Engineering Reports (Drainage, Utility, Roadway Plans, ITS, Lighting, Pavement, Geotech, PER) | 30d | 2019-07-08 | 2019-08-16 | 74, 24, 97 | 0d |  |  |
| 113 |  | FDOT Review - 1st DRAFT Engineering Reports | 20d | 2019-08-19 | 2019-09-13 | 112 | 0d |  |  |
| 114 |  | Update DRAFT Engineering Reports | 15d | 2019-09-16 | 2019-10-04 | 113 | 0d |  |  |
| 115 |  | VE Study | 5d | 2019-10-07 | 2019-10-11 | 114 | 0d |  |  |
| 116 |  | VE Issues Resolution | 10d | 2019-11-11 | 2019-11-22 | 115 FS+2.5d | 0d |  |  |
| 117 |  | Prepare Typical Section Package | 20d | 2019-11-25 | 2019-12-20 | 116 | 0d |  |  |
| 118 |  | Prepare Design Variations and Exceptions | 20d | 2019-11-25 | 2019-12-20 | 116 | 0d |  |  |
| 119 |  | Prepare Pavement Design Report | 20d | 2019-11-25 | 2019-12-20 | 98, 116 | 0d |  |  |
| 120 |  | Typical Section Selection | 20d | 2019-12-23 | 2020-01-17 | 117, 118, 119 | 0d |  | 759 |
| 121 |  | FDOT Review - 2nd DRAFT Engineering Reports (Drainage, Utility, Roadway Plans, ITS, Lighting, Pavement, Geotech, PER) | 20d | 2019-12-23 | 2020-01-17 | 117 | 354d | 16d |  |
|  | 3.4 | **ENVIRONMENTAL ANALYSIS** |  | 2019-04-12 | 2019-12-23 |  |  |  |  |
| 123 |  | Data Collection & Cultural Resources Assessment Survey | 40d | 2019-04-12 | 2019-06-06 | 107 | 0d |  |  |
| 124 |  | Data Collection & Noise Analysis | 40d | 2019-04-12 | 2019-06-06 | 107 | 0d |  |  |
| 125 |  | Data Collection & Contamination Screen Evaluation | 40d | 2019-04-12 | 2019-06-06 | 107 | 0d |  |  |
| 126 |  | Wetland Delineation and Evaluation | 40d | 2019-04-12 | 2019-06-06 | 107 | 0d |  |  |
| 127 |  | Data Collection & Wildlife Survey | 40d | 2019-04-12 | 2019-06-06 | 107 | 0d |  |  |
| 128 |  | Essential Fish Habitat Evaluation | 40d | 2019-04-12 | 2019-06-06 | 107 | 0d |  |  |
| 129 |  | Determination of Section 4(f) | 15d | 2019-04-12 | 2019-05-02 | 107 | 409d | 0d |  |
| 134 |  | Prepare Draft Section 4(f) Evaluation | 30d | 2019-05-03 | 2019-06-13 | 129 | 409d | 25d |  |
| 130 |  | Prepare 1st Draft Natural Resource Evaluation Report | 30d | 2019-06-07 | 2019-07-18 | 126, 127, 128 | 384d | 0d |  |
| 131 |  | Prepare 1st Draft Cultural Resources Assessment Survey | 30d | 2019-06-07 | 2019-07-18 | 123 | 384d | 0d |  |
| 132 |  | Prepare 1st Draft Contamination Screen Evaluation Report | 30d | 2019-06-07 | 2019-07-18 | 125 | 384d | 0d |  |
| 133 |  | Prepare 1st Draft Noise Study Report | 30d | 2019-06-07 | 2019-07-18 | 124 | 384d | 0d |  |
| 135 |  | FDOT Review 1st DRAFT Environmental Reports (NRE, CSER, CRAS, Noise, Section 4(f)) | 20d | 2019-07-19 | 2019-08-15 | 130, 131, 132, 133, 134 | 384d | 0d |  |
| 136 |  | Update Environmental Reports | 15d | 2019-08-16 | 2019-09-05 | 135 | 384d | 0d |  |
| 137 |  | Finalize Cultural Resources Assessment Survey | 10d | 2019-09-06 | 2019-09-19 | 136 | 384d | 46d | 333 |
| 138 |  | Finalize Natural Resource Evaluation Report | 10d | 2019-09-06 | 2019-09-19 | 136 | 394d | 46d | 761 |
| 139 |  | Submit CRAS to OEM | 20d | 2019-11-25 | 2019-12-20 | 136, 116, 137 | 338d | 0d |  |
| 141 |  | Submit NRE to USFWS | 1d | 2019-11-25 | 2019-11-25 | 116, 138 | 348d | 0d |  |
| 142 |  | Submit NRE to NMFS | 1d | 2019-11-25 | 2019-11-25 | 116, 138 | 348d | 0d |  |
| 145 |  | Prepare Conceptual Relocation Plan | 20d | 2019-11-25 | 2019-12-20 | 116 | 339d | 1d |  |
| 143 |  | Informal USFWS Consultation Complete | 10d | 2019-11-26 | 2019-12-09 | 141 | 348d | 10d | 752 |
| 144 |  | Informal NMFS Consultation Complete | 10d | 2019-11-26 | 2019-12-09 | 142 | 348d | 10d | 763 |
| 140 |  | SHPO Consultation Complete | 1d | 2019-12-23 | 2019-12-23 | 139 | 338d | 0d | 762 |

| ID | WBS | Activity | Duration | Start | Finish | Predecessors | Total float | Free float | Stack/Buffer |
| --- | --- | --- | --- | --- | --- | --- | --- | --- | --- |
|  | 3.5 | **FINAL CE TYPE II DOCUMENTS** |  | 2019-12-24 | 2020-05-08 |  |  |  |  |
| 147 |  | Prepare DRAFT Type II CE | 20d | 2019-12-24 | 2020-01-20 | 116, 11, 140, 143, 144, 145, 8 | 338d | 0d |  |
| 148 |  | FDOT Review DRAFT Type II CE | 20d | 2020-01-21 | 2020-02-17 | 147 | 338d | 0d | 713 |
| 149 |  | Finalize Engineering & Environmental Reports | 10d | 2020-03-18 | 2020-03-31 | 83 | 343d | 5d | 756 |
| 150 |  | Finalize Section 4(f) Evaluation | 5d | 2020-03-18 | 2020-03-24 | 83 | 338d | 0d | 751 |
| 151 |  | Finalize Noise Study Report | 5d | 2020-03-18 | 2020-03-24 | 83 | 338d | 0d | 335 |
| 152 |  | Finalize Preliminary Engineering Report | 5d | 2020-03-18 | 2020-03-24 | 83 | 348d | 10d | 760 |
| 153 |  | Prepare FINAL Type II CE | 10d | 2020-03-25 | 2020-04-07 | 83, 150, 151 | 338d | 0d |  |
| 154 |  | Submit Type 2 CE to OEM | 20d | 2020-04-08 | 2020-05-05 | 153, 149, 152 | 338d | 0d |  |
| 155 |  | OEM Approval of Type II CE | 1d | 2020-05-06 | 2020-05-06 | 154 | 338d | 0d | 722 |
| 156 |  | Location Design Concept Acceptance | 1d | 2020-05-07 | 2020-05-07 | 154, 155 | 338d | 0d | 263 |
| 157 |  | Location Design Concept Public Notice | 1d | 2020-05-08 | 2020-05-08 | 156 | 338d |  | 736 |
|  | 4 | **FINAL DESIGN** |  | 2020-01-20 | 2021-08-25 |  |  |  |  |
|  | 4.1 | **60% (PHASE II) PLANS** |  | 2020-01-20 | 2020-06-30 |  |  |  |  |
| 160 |  | Prepare 60% (Phase II) Plans | 80d | 2020-01-20 | 2020-05-08 | 120 | 0d |  |  |
| 161 |  | Submit 60% Plans & Quantities to FDOT | 1d | 2020-05-11 | 2020-05-11 | 160 | 0d |  | 302 |
| 162 |  | FDOT Review of Phase II Plans | 20d | 2020-05-12 | 2020-06-08 | 161 | 44d | 0d |  |
| 163 |  | Utility Review & Conflict Resolution | 15d | 2020-06-09 | 2020-06-29 | 162 | 44d | 0d |  |
| 164 |  | Prepare and Submit Permit Applications | 15d | 2020-06-09 | 2020-06-29 | 162 | 45d | 1d |  |
| 165 |  | ROW Coordination Meeting 60% | 1d | 2020-06-30 | 2020-06-30 | 163 | 44d | 0d |  |
|  | 4.2 | **90% (PHASE III) PLANS** |  | 2020-07-01 | 2020-10-29 |  |  |  |  |
| 167 |  | Prepare 90% (Phase III) Plans & Quantities | 50d | 2020-07-01 | 2020-09-08 | 164, 165 | 44d | 0d |  |
| 168 |  | Submit 90% Plans & Quantities to FDOT | 1d | 2020-09-09 | 2020-09-09 | 167 | 44d | 0d | 303 |
| 169 |  | FDOT Review of 90% Plans | 20d | 2020-09-10 | 2020-10-07 | 168 | 44d | 0d |  |
| 170 |  | Utility Review & Conflict Resolution | 15d | 2020-10-08 | 2020-10-28 | 169 | 44d | 0d |  |
| 171 |  | ROW Coordination Meeting 90% | 1d | 2020-10-29 | 2020-10-29 | 170 | 44d | 0d |  |

| ID | WBS | Activity | Duration | Start | Finish | Predecessors | Total float | Free float | Stack/Buffer |
| --- | --- | --- | --- | --- | --- | --- | --- | --- | --- |
|  | 4.3 | **100% (PHASE IV) PLANS** |  | 2020-10-30 | 2021-01-08 |  |  |  |  |
| 173 |  | Prepare 100% (Phase IV) Submittal | 30d | 2020-10-30 | 2020-12-10 | 171 | 44d | 0d |  |
| 174 |  | Submit 100% (Phase IV) Submittal to FDOT | 1d | 2020-12-11 | 2020-12-11 | 173 | 44d | 0d | 306 |
| 175 |  | FDOT Review of 100% (Phase IV) Submittal | 20d | 2020-12-14 | 2021-01-08 | 174 | 44d | 0d |  |
|  | 4.4 | **RIGHT OF WAY AQUISITION** |  | 2020-01-20 | 2021-07-02 |  |  |  |  |
| 177 |  | Determine and Submit ROW Requirements to R/W Office | 60d | 2020-01-20 | 2020-04-10 | 120 | 21d |  | 322 |
| 178 |  | Final ROW Map/Sketches and Legals to R/W Administration | 20d | 2020-05-12 | 2020-06-08 | 161, 177 | 0d |  | 139 |
| 179 |  | Submit Documents to R/W Administration | 1d | 2020-06-09 | 2020-06-09 | 178 | 0d |  | 268 |
| 180 |  | Apraisals Review | 1d | 2020-06-10 | 2020-06-10 | 179 | 0d |  | 143 |
| 181 |  | Perform R/W Appraisals | 120d | 2020-06-11 | 2020-11-25 | 180 | 0d |  | 120 |
| 182 |  | Negotiations and Land Acquisition | 120d | 2020-09-03 | 2021-02-17 | 181 SS+7.5d | 0d |  | 121 |
| 183 |  | Final ROW Order of Taking | 1d | 2021-02-18 | 2021-02-18 | 182 | 0d |  | 273 |
| 184 |  | Condemnation | 60d | 2021-02-19 | 2021-05-13 | 183 | 0d |  | 122 |
| 185 |  | ROW Demo & Clear | 60d | 2021-04-02 | 2021-06-24 | 184 SS+3.75d | 0d |  | 125 |
| 186 |  | ROW Certified | 1d | 2021-07-02 | 2021-07-02 | 185 FS+0.62d | 0d |  | 255 |
|  | 4.5 | **FINAL PLANS** |  | 2021-01-11 | 2021-07-12 |  |  |  |  |
| 188 |  | Plans Completed | 60d | 2021-01-11 | 2021-04-02 | 175 | 44d | 0d | 201 |
| 189 |  | Review Final Plans by Estimate & Construction Office | 20d | 2021-04-05 | 2021-04-30 | 188 | 44d | 0d |  |
| 190 |  | ADA Certification | 1d | 2021-05-10 | 2021-05-10 | 189 FS+0.62d | 44d |  |  |
| 191 |  | All Permits Clear | 1d | 2021-05-10 | 2021-05-10 | 189 FS+0.62d | 44d |  | 222 |
| 192 |  | Utilities Clear | 1d | 2021-05-10 | 2021-05-10 | 189 FS+0.62d | 44d |  | 269 |
| 193 |  | Railroad Clear | 1d | 2021-05-10 | 2021-05-10 | 189 FS+0.62d | 44d |  | 279 |
| 194 |  | Construction Clear | 1d | 2021-05-10 | 2021-05-10 | 189 FS+0.62d | 44d |  | 375 |
| 195 |  | Environmental Clear | 1d | 2021-05-10 | 2021-05-10 | 189 FS+0.62d | 44d |  | 376 |
| 196 |  | Production Date | 1d | 2021-07-12 | 2021-07-12 | 186 FS+0.62d, 190, 191, 192, 193, 194, 195 | 0d |  | 204 |

| ID | WBS | Activity | Duration | Start | Finish | Predecessors | Planned start | Planned finish | Total float | Stack/Buffer |
| --- | --- | --- | --- | --- | --- | --- | --- | --- | --- | --- |
|  | 4.6 | **SPECIFICATIONS PACKAGE** |  | 2021-07-13 | 2021-08-25 |  |  |  |  |  |
| 198 |  | Plans to Specs | 1d | 2021-07-13 | 2021-07-13 | 196 |  |  | 0d | 226 |
| 199 |  | Prepare Specifications Package | 21d | 2021-07-14 | 2021-08-11 | 196, 198 |  |  | 0d | 242 |
| 200 |  | PLANS TO TALLAHASSEE | 0d | 2021-08-25 | 2021-08-25 | 199 FS+1.25d | 2021-08-26 | 2021-08-26 | 0d | 212 |
